# Preliminary Requirements Phase Gantt Chart

Schedule from MS Project, 2009-02-01 to 2009-03-05.
Project Perfect

## Calendars

- Standard: Mon-Fri 08:00-12:00, 13:00-17:00; Sat-Sun off.

## Schedule

| ID | WBS | Task | Type | Duration | Start | Finish | Predecessors | Total slack | Free slack |
| --- | --- | --- | --- | --- | --- | --- | --- | --- | --- |
| 1 | 1 | NOTE: All time estimates are duration rather than work. They will have to be scaled up or down to suit the project. | milestone | 0d | 2009-02-01 | 2009-02-01 |  | 20.6d |  |
| 4 | 2 | **Phase Planning** |  | 2.3d | 2009-02-02 | 2009-02-04 |  | 0.4d |  |
| 5 | 2.1 | Review the draft plan and look for changes |  | 0.2d | 2009-02-02 | 2009-02-02 |  | 0.4d | 0d |
| 6 | 2.2 | Prepare a schedule (Gantt Chart) |  | 0.2d | 2009-02-02 | 2009-02-02 | 5 | 0.4d | 0d |
| 7 | 2.3 | Allocate resources |  | 0.2d | 2009-02-02 | 2009-02-02 | 6 | 0.4d | 0d |
| 8 | 2.4 | Confirm resource availability |  | 0.5d | 2009-02-02 | 2009-02-03 | 7 | 0.4d | 0d |
| 9 | 2.5 | Revise list of issues and risks |  | 0.2d | 2009-02-03 | 2009-02-03 | 8 | 0.4d | 0d |
| 10 | 2.6 | Gain agreement to proceed |  | 1d | 2009-02-03 | 2009-02-04 | 9 | 0.4d | 0d |
| 11 | 2.7 | Planning complete | milestone | 0d | 2009-02-04 | 2009-02-04 | 10 | 0.4d | 0d |
| 12 | 3 | **Kick Off Meeting** |  | 2.2d | 2009-02-02 | 2009-02-04 |  | 0d |  |
| 13 | 3.1 | Schedule meeting |  | 2d | 2009-02-02 | 2009-02-03 |  | 0d |  |
| 14 | 3.2 | Prepare material |  | 1d | 2009-02-02 | 2009-02-02 |  | 1d |  |
| 15 | 3.3 | Hold meeting |  | 0.2d | 2009-02-04 | 2009-02-04 | 13, 14 | 0d |  |
| 16 | 3.4 | Kick Off meeting complete | milestone | 0d | 2009-02-04 | 2009-02-04 | 15 | 0d |  |
| 17 | 4 | **Functional Requirments** |  | 7.5d | 2009-02-04 | 2009-02-13 | 11 | 0.4d |  |
| 18 | 4.1 | Schedule Workshop |  | 5d | 2009-02-04 | 2009-02-11 |  | 0.4d | 0d |
| 19 | 4.2 | Hold Workshop |  | 1d | 2009-02-11 | 2009-02-12 | 18 | 0.4d | 0d |
| 20 | 4.3 | Complete functional decomposition |  | 0.5d | 2009-02-12 | 2009-02-12 | 19 | 0.4d | 0d |
| 21 | 4.4 | Carry out QA |  | 0.5d | 2009-02-12 | 2009-02-13 | 20 | 0.4d | 0d |
| 22 | 4.5 | Carry out rework |  | 0.5d | 2009-02-13 | 2009-02-13 | 21 | 0.4d | 0d |
| 23 | 4.6 | Functional decomposition complete | milestone | 0d | 2009-02-13 | 2009-02-13 | 22 | 0.4d |  |
| 24 | 4.7 | **Data Requirments** |  | 7.5d | 2009-02-04 | 2009-02-13 | 11 | 0.4d |  |
| 25 | 4.7.1 | Schedule Workshop |  | 5d | 2009-02-04 | 2009-02-11 |  | 0.4d | 0d |
| 26 | 4.7.2 | Hold Workshop |  | 1d | 2009-02-11 | 2009-02-12 | 25 | 0.4d | 0d |
| 27 | 4.7.3 | Complete data modeling |  | 0.5d | 2009-02-12 | 2009-02-12 | 26 | 0.4d | 0d |
| 28 | 4.7.4 | Carry out QA |  | 0.5d | 2009-02-12 | 2009-02-13 | 27 | 0.4d | 0d |
| 29 | 4.7.5 | Carry out rework |  | 0.5d | 2009-02-13 | 2009-02-13 | 28 | 0.4d | 0d |
| 30 | 4.7.6 | Data modeling complete | milestone | 0d | 2009-02-13 | 2009-02-13 | 29 | 0.4d |  |

| ID | WBS | Task | Type | Duration | Start | Finish | Predecessors | Total slack |
| --- | --- | --- | --- | --- | --- | --- | --- | --- |
| 31 | 5 | **Business Processes** |  | 8d | 2009-02-04 | 2009-02-16 | 16 | 0d |
| 32 | 5.1 | Review processes |  | 5d | 2009-02-04 | 2009-02-11 |  | 0d |
| 33 | 5.2 | Document processes |  | 1d | 2009-02-11 | 2009-02-12 | 32 | 0d |
| 34 | 5.3 | Confirm processes |  | 1d | 2009-02-12 | 2009-02-13 | 33 | 0d |
| 35 | 5.4 | Carry out rework |  | 1d | 2009-02-13 | 2009-02-16 | 34 | 0d |
| 36 | 5.5 | Business Processes complete | milestone | 0d | 2009-02-16 | 2009-02-16 | 35 | 0d |
| 37 | 6 | **Report** |  | 11.5d | 2009-02-16 | 2009-03-03 | 36, 23, 30 | 0d |
| 38 | 6.1 | Update High Level Scope |  | 0.5d | 2009-02-16 | 2009-02-16 |  | 0d |
| 39 | 6.2 | Identify major impacts |  | 0.5d | 2009-02-16 | 2009-02-17 | 38 | 12.4d |
| 40 | 6.3 | Identify "Deal Breakers" |  | 5d | 2009-02-16 | 2009-02-23 | 38 | 0d |
| 41 | 6.4 | Identify potential solutions |  | 2d | 2009-02-23 | 2009-02-25 | 40 | 0d |
| 42 | 6.5 | Produce report |  | 2d | 2009-02-25 | 2009-02-27 | 41 | 0d |
| 43 | 6.6 | Carry out QA |  | 0.5d | 2009-02-27 | 2009-03-02 | 42 | 0d |
| 44 | 6.7 | Carry out rework |  | 1d | 2009-03-02 | 2009-03-03 | 43 | 0d |
| 45 | 6.8 | Present report |  | 0.5d | 2009-03-03 | 2009-03-03 | 44 | 0d |
| 46 | 6.9 | Report complete | milestone | 0d | 2009-03-03 | 2009-03-03 | 45 | 0d |
| 47 | 7 | **Closure** |  | 1.9d | 2009-03-03 | 2009-03-05 | 46 | 0d |
| 48 | 7.1 | Produce plan for next phase |  | 0.4d | 2009-03-03 | 2009-03-04 |  | 0d |
| 49 | 7.2 | Agree plan with the Sponsor |  | 1d | 2009-03-04 | 2009-03-05 | 48 | 0d |
| 50 | 7.3 | Agree to proceed through the gate to the next phase |  | 0.5d | 2009-03-05 | 2009-03-05 | 49 | 0d |
| 51 | 7.4 | Phase complete | milestone | 0d | 2009-03-05 | 2009-03-05 | 50 | 0d |
